# CRONOGRAMA PROYECTO BIOSUELOS DE SANTANDER 31-01-2022

Schedule from MS Project, 2021-08-02 to 2022-04-26, status date 2022-01-31, 9 hours a day, costs in $, A marks actual dates.

## Calendars

- PROYECTO BIOSUELOS: Mon-Fri 08:00-13:00, 14:00-18:00; Sat-Sun off. Exceptions (off unless hours are given): 2021-08-07 (FESTIVO BATALLA DE BOYACA), 2021-08-16 (FESTIVO LA ASUNCION DE LA VIRGEN), 2021-10-18 (FESTIVO DIA DE LA RAZA), 2021-11-01 (FESTIVO TODOS LOS SANTOS), 2021-11-15 (FESTIVO INDEPENDIA DE CARTAGENA), 2021-12-08 (FESTIVO INMACULADA CONCEPCION), 2021-12-25 (FESTIVO NAVIDAD), 2022-01-01 (FESTIVO AÑO NUEVO), 2022-01-10 (FESTIVO REYES MAGOS), 2022-03-21 (FESTIVO SAN JOSE), 2022-04-10 (FESTIVO DOMINGO DE RAMOS), 2022-04-14 (FESTIVO JUEVES SANTO), 2022-04-15 (FESTIVO VIERNES SANTO), 2022-04-17 (FESTIVO DOMINGO DE RESURECCION).

## Resources

| Resource | Group | Unit | Rate |
| --- | --- | --- | --- |
| Gerente de Proyectos | EQUIPO DE PROYECTO |  | 18750 |
| Ingeniero de sistemas | EQUIPO DE PROYECTO |  | 9583 |
| Ingeniero ambiental | EQUIPO DE PROYECTO |  | 12500 |
| Ingenieros de proyectos | EQUIPO DE PROYECTO |  | 10417 |
| Tecnico de proyectos | EQUIPO DE PROYECTO |  | 10417 |
| Computador | EQUIPO DE PROYECTO | x mensualidad | 80000 |
| Impresora | EQUIPO DE PROYECTO | x mensualidad | 17000 |
| Papel | EQUIPO DE PROYECTO | x resma | 15000 |
| Gasolina | EQUIPO DE PROYECTO | x galon | 8900 |
| Celular | EQUIPO DE PROYECTO | x mensualidad | 15000 |
| Plan de minutos /Datos | EQUIPO DE PROYECTO | x mensualidad | 35000 |
| Memoria USB | EQUIPO DE PROYECTO | X unidad | 22500 |
| Esferos | EQUIPO DE PROYECTO | X unidad | 492 |
| Agenda | EQUIPO DE PROYECTO | x unidad | 8000 |

## Schedule

| ID | WBS | Task | Type | Duration | Start | Finish | Predecessors | Complete | Remaining | Baseline start | Baseline finish | Baseline duration | Total slack | Constraint | Resources | Work | Actual work | Cost | Baseline cost | Actual cost |
| --- | --- | --- | --- | --- | --- | --- | --- | --- | --- | --- | --- | --- | --- | --- | --- | --- | --- | --- | --- | --- |
| 1 | 1 | **REESTRUCTURACION ORGANIZACIONAL BIOSUELOS DE SANTANDER** |  | 182.67d | 2021-08-02 A | 2022-04-26 |  | 78% | 40.2d | 2021-08-02 | 2022-04-26 | 182.67d | 0d |  |  | 1463.08h | 1063.84h | 26,197,782.68 | 26,294,824.11 | 17,830,244.95 |
| 2 | 1.1 | Inicio del Proyecto | milestone, manual | 0d | 2021-08-02 | 2021-08-02 |  |  |  | 2021-08-02 | 2021-08-02 | 0d |  |  |  |  |  |  |  |  |
| 3 | 1.2 | **INFORME DIAGNOSTICO INICIAL DE LA EMPRESA** |  | 43.5d | 2021-08-02 A | 2021-10-01 A |  | 100% |  | 2021-08-02 | 2021-10-01 | 43.5d |  |  |  | 301.79h | 301.79h | 5,624,772.3 | 5,453,038.38 | 5,624,772.3 |
| 4 | 1.2.1 | **INVESTIGACION** |  | 20.83d | 2021-08-02 A | 2021-08-31 A |  | 100% |  | 2021-08-02 | 2021-08-31 | 20.83d |  |  |  | 196.46h | 196.46h | 3,500,000 | 3,534,665.8 | 3,500,000 |
| 5 | 1.2.1.1 | REVISION DE ESTANDARES Y PROCESOS ACTUALES |  | 20.83d | 2021-08-02 A | 2021-08-31 A | 2 | 100% |  | 2021-08-02 | 2021-08-31 | 20.83d |  | start no earlier than 2021-08-02 | Gerente de Proyectos [40%]; Ingenieros de proyectos [40%]; Ingeniero ambiental [10%]; Computador [3 x mensualidad]; Celular [3 x mensualidad]; Agenda [3 x unidad]; Impresora [1 x mensualidad]; Papel [1 x resma]; Memoria USB [3 X unidad]; Plan de minutos /Datos [3 x mensualidad]; Esferos [2 X unidad] | 149.98h | 149.98h | 2,300,000 | 2,666,939.55 | 2,300,000 |
| 6 | 1.2.1.2 | VISITA DE CAMPO |  | 10.33d | 2021-08-02 A | 2021-08-17 A | 2 | 100% |  | 2021-08-02 | 2021-08-17 | 10.33d |  |  | Tecnico de proyectos [50%]; Computador [1 x mensualidad]; Plan de minutos /Datos [1 x mensualidad]; Celular [1 x mensualidad]; Esferos [1 X unidad]; Agenda [1 x unidad]; Memoria USB [1 X unidad]; Gasolina [25 x galon] | 46.48h | 46.48h | 1,200,000 | 867,726.24 | 1,200,000 |
| 7 | 1.2.2 | **ANALISIS** |  | 22.67d | 2021-08-31 A | 2021-10-01 A |  | 100% |  | 2021-08-31 | 2021-10-01 | 22.67d |  |  |  | 105.33h | 105.33h | 2,124,772.3 | 1,918,372.58 | 2,124,772.3 |
| 8 | 1.2.2.1 | ANALISIS DE RESULTADO DE REVISION Y TRABAJO DE CAMPO |  | 14.5d | 2021-08-31 A | 2021-09-21 A | 5, 6 | 100% |  | 2021-08-31 | 2021-09-21 | 14.5d |  |  | Ingeniero ambiental [10%]; Ingenieros de proyectos [10%]; Computador [2 x mensualidad]; Celular [2 x mensualidad]; Plan de minutos /Datos [2 x mensualidad] | 39.15h | 39.15h | 915,000 | 708,600.28 | 915,000 |
| 9 | 1.2.2.2 | CONCLUSIONES Y RECOMENDACIONES |  | 8.17d | 2021-09-21 A | 2021-10-01 A | 8 | 100% |  | 2021-09-21 | 2021-10-01 | 8.17d |  |  | Gerente de Proyectos [40%]; Ingeniero ambiental [10%]; Ingenieros de proyectos [40%]; Celular [2 x mensualidad]; Computador [2 x mensualidad]; Plan de minutos /Datos [2 x mensualidad] | 66.18h | 66.18h | 1,209,772.3 | 1,209,772.3 | 1,209,772.3 |
| 10 | 1.3 | **DOCUMENTOS DE NUEVOS ESTANDARES** |  | 30.33d | 2021-10-01 A | 2021-11-17 A |  | 100% |  | 2021-10-01 | 2021-11-17 | 30.33d |  |  |  | 442.78h | 442.78h | 7,264,546.32 | 7,347,912.08 | 7,264,546.32 |
| 11 | 1.3.1 | **DESARROLLO DE NUEVOS PROCESOS** |  | 15d | 2021-10-01 A | 2021-10-25 A |  | 100% |  | 2021-10-01 | 2021-10-25 | 15d |  |  |  | 182.38h | 182.38h | 2,979,124.92 | 2,979,124.92 | 2,979,124.92 |
| 12 | 1.3.1.1 | DESARROLLO DE PROCESO DE GESTION |  | 15d | 2021-10-01 A | 2021-10-25 A | 9 | 100% |  | 2021-10-01 | 2021-10-25 | 15d |  |  | Ingeniero ambiental [10%]; Ingenieros de proyectos [15%]; Computador [2 x mensualidad]; Celular [2 x mensualidad]; Plan de minutos /Datos [2 x mensualidad] | 40.5h | 40.5h | 724,069.25 | 724,069.25 | 724,069.25 |
| 13 | 1.3.1.2 | DESARROLLO DE PROCESOS ADMINISTRATIVOS |  | 10.33d | 2021-10-01 A | 2021-10-15 A | 9 | 100% |  | 2021-10-01 | 2021-10-15 | 10.33d |  |  | Ingenieros de proyectos [40%]; Gerente de Proyectos [40%]; Tecnico de proyectos [50%]; Celular [3 x mensualidad]; Computador [3 x mensualidad]; Plan de minutos /Datos [3 x mensualidad] | 74.38h | 74.38h | 1,291,908.17 | 1,291,908.17 | 1,291,908.17 |
| 14 | 1.3.1.3 | DESARROLLO DE PROCESO OPERATIVO |  | 7.5d | 2021-10-01 A | 2021-10-12 A | 9 | 100% |  | 2021-10-01 | 2021-10-12 | 7.5d |  |  | Ingenieros de proyectos [50%]; Tecnico de proyectos [50%]; Celular [2 x mensualidad]; Computador [2 x mensualidad]; Plan de minutos /Datos [2 x mensualidad] | 67.5h | 67.5h | 963,147.5 | 963,147.5 | 963,147.5 |
| 15 | 1.3.2 | **DEFINICION DE ROLES Y RESPONSABILIDADES** |  | 15.33d | 2021-10-25 A | 2021-11-17 A |  | 100% |  | 2021-10-25 | 2021-11-17 | 15.33d |  |  |  | 110.38h | 110.38h | 2,129,668.4 | 2,129,668.4 | 2,129,668.4 |
| 16 | 1.3.2.1 | DEFINIR OBJETIVO DEL EQUIPO DE ACUERDO A NUEVOS PROCESOS |  | 10.33d | 2021-10-25 A | 2021-11-09 A | 12, 13, 14 | 100% |  | 2021-10-25 | 2021-11-09 | 10.33d |  |  | Gerente de Proyectos [40%]; Ingenieros de proyectos [40%]; Celular [2 x mensualidad]; Computador [2 x mensualidad]; Plan de minutos /Datos [2 x mensualidad] | 74.38h | 74.38h | 1,344,662.4 | 1,344,662.4 | 1,344,662.4 |
| 17 | 1.3.2.2 | DEFINIR NUEVA ESTRUCTURA ORGANIZACIONAL EMPRESA |  | 5d | 2021-11-09 A | 2021-11-17 A | 16 | 100% |  | 2021-11-09 | 2021-11-17 | 5d |  |  | Gerente de Proyectos [40%]; Ingenieros de proyectos [40%]; Celular [2 x mensualidad]; Computador [2 x mensualidad]; Plan de minutos /Datos [2 x mensualidad] | 36h | 36h | 785,006 | 785,006 | 785,006 |
| 18 | 1.3.3 | **DESARROLLO DE NUEVOS FORMATOS** |  | 14.67d | 2021-10-25 A | 2021-11-17 A |  | 100% |  | 2021-10-25 | 2021-11-17 | 14.67d |  |  |  | 150.03h | 150.03h | 2,155,753 | 2,239,118.76 | 2,155,753 |
| 19 | 1.3.3.1 | FORMATOS ENTRADA Y SALIDA DE PROCESOS |  | 14.67d | 2021-10-25 A | 2021-11-17 A | 12, 13, 14 | 100% |  | 2021-10-25 | 2021-11-17 | 14.67d |  |  | Ingeniero ambiental [10%]; Tecnico de proyectos [16.7%]; Celular [2 x mensualidad]; Computador [2 x mensualidad]; Plan de minutos /Datos [2 x mensualidad] | 132.03h | 132.03h | 1,689,500 | 1,772,865.76 | 1,689,500 |
| 20 | 1.3.3.2 | FORMATOS EVALUACION Y CONTROL |  | 10d | 2021-10-25 A | 2021-11-09 A | 12, 13, 14 | 100% |  | 2021-10-25 | 2021-11-09 | 10d |  |  | Ingeniero ambiental [10%]; Tecnico de proyectos [10%]; Celular [2 x mensualidad]; Computador [2 x mensualidad]; Plan de minutos /Datos [2 x mensualidad] | 18h | 18h | 466,253 | 466,253 | 466,253 |
| 21 | 1.4 | **ACTA DE APROBACION DE NUEVOS ESTANDARES** |  | 21.17d | 2021-11-17 A | 2021-12-17 A |  | 100% |  | 2021-11-17 | 2021-12-17 | 21.17d |  |  |  | 112.21h | 112.21h | 2,413,575 | 2,598,984.6 | 2,413,575 |
| 22 | 1.4.1 | **SOCIALIZACION NUEVOS ESTANDARES** |  | 8d | 2021-11-17 A | 2021-11-29 A |  | 100% |  | 2021-11-17 | 2021-11-29 | 8d |  |  |  | 64.8h | 64.8h | 1,264,600 | 1,450,009.6 | 1,264,600 |
| 23 | 1.4.1.1 | PRESENTACION PRELIMINAR A SPONSOR |  | 3d | 2021-11-17 A | 2021-11-22 A | 17, 19, 20 | 100% |  | 2021-11-17 | 2021-11-22 | 3d |  |  | Gerente de Proyectos [40%]; Ingeniero ambiental [10%]; Ingenieros de proyectos [40%]; Computador [2 x mensualidad]; Celular [2 x mensualidad]; Plan de minutos /Datos [2 x mensualidad] | 24.3h | 24.3h | 589,600 | 608,753.6 | 589,600 |
| 24 | 1.4.1.2 | PRESENTACION PRELIMINAR A TODOS LOS INTERESADOS |  | 5d | 2021-11-22 A | 2021-11-29 A | 23 | 100% |  | 2021-11-22 | 2021-11-29 | 5d |  |  | Gerente de Proyectos [40%]; Ingeniero ambiental [10%]; Ingenieros de proyectos [40%]; Celular [2 x mensualidad]; Computador [2 x mensualidad]; Plan de minutos /Datos [2 x mensualidad] | 40.5h | 40.5h | 675,000 | 841,256 | 675,000 |

| ID | WBS | Task | Type | Duration | Start | Finish | Predecessors | Complete | Remaining | Baseline start | Baseline finish | Baseline duration | Total slack | Resources | Work | Actual work | Cost | Baseline cost | Actual cost |
| --- | --- | --- | --- | --- | --- | --- | --- | --- | --- | --- | --- | --- | --- | --- | --- | --- | --- | --- | --- |
| 25 | 1.4.2 | **EVALUACION Y APROBACION** |  | 13.17d | 2021-11-29 A | 2021-12-17 A |  | 100% |  | 2021-11-29 | 2021-12-17 | 13.17d |  |  | 47.41h | 47.41h | 1,148,975 | 1,148,975 | 1,148,975 |
| 26 | 1.4.2.1 | CONCLUSIONES DE SPONSOR E INTERESADOS |  | 8d | 2021-11-29 A | 2021-12-10 A | 23, 24 | 100% |  | 2021-11-29 | 2021-12-10 | 8d |  | Gerente de Proyectos [40%]; Celular [1 x mensualidad]; Computador [1 x mensualidad]; Plan de minutos /Datos [1 x mensualidad] | 28.8h | 28.8h | 670,000 | 670,000 | 670,000 |
| 27 | 1.4.2.2 | APROBACION DE NUEVOS ESTANDARES |  | 5.17d | 2021-12-10 A | 2021-12-17 A | 26 | 100% |  | 2021-12-10 | 2021-12-17 | 5.17d |  | Gerente de Proyectos [40%]; Celular [1 x mensualidad]; Computador [1 x mensualidad]; Plan de minutos /Datos [1 x mensualidad] | 18.61h | 18.61h | 478,975 | 478,975 | 478,975 |
| 28 | 1.5 | **PAGINA WEB** |  | 50.01d | 2021-12-20 A | 2022-03-01 |  | 72% | 14.17d | 2021-12-20 | 2022-03-01 | 50.01d | 0d |  | 270.81h | 207.05h | 3,314,332.25 | 3,314,332.25 | 2,527,351.33 |
| 29 | 1.5.1 | **DISEÑO** |  | 22.84d | 2021-12-20 A | 2022-01-20 A |  | 100% |  | 2021-12-20 | 2022-01-20 | 22.84d |  |  | 148.54h | 148.54h | 1,882,666.75 | 1,882,666.75 | 1,882,666.75 |
| 30 | 1.5.1.1 | LEVANTAMIENTO DE REQUERIMIENTOS |  | 10.17d | 2021-12-20 A | 2022-01-03 A | 27 | 100% |  | 2021-12-20 | 2022-01-03 | 10.17d |  | Ingeniero de sistemas [50%]; Ingenieros de proyectos [50%]; Agenda [1 x unidad]; Celular [2 x mensualidad]; Computador [2 x mensualidad]; Plan de minutos /Datos [2 x mensualidad]; Esferos [1 X unidad] | 91.53h | 91.53h | 1,183,792 | 1,183,792 | 1,183,792 |
| 31 | 1.5.1.2 | DISEÑO GRAFICO |  | 12.67d | 2022-01-03 A | 2022-01-20 A | 27, 30 | 100% |  | 2022-01-03 | 2022-01-20 | 12.67d |  | Ingeniero de sistemas [50%]; Celular [1 x mensualidad]; Computador [1 x mensualidad]; Plan de minutos /Datos [1 x mensualidad]; Memoria USB [1 X unidad] | 57.02h | 57.02h | 698,874.75 | 698,874.75 | 698,874.75 |
| 32 | 1.5.2 | **IMPLEMENTACION** |  | 27.17d | 2022-01-20 A | 2022-03-01 |  | 48% | 14.17d | 2022-01-20 | 2022-03-01 | 27.17d | 0d |  | 122.27h | 58.51h | 1,431,665.5 | 1,431,665.5 | 644,684.58 |
| 33 | 1.5.2.1 | DESARROLLO |  | 21.67d | 2022-01-20 A | 2022-02-21 | 30, 31 | 60% | 8.67d | 2022-01-20 | 2022-02-21 | 21.67d | 0d | Ingeniero de sistemas [50%]; Celular [1 x mensualidad]; Computador [1 x mensualidad]; Plan de minutos /Datos [1 x mensualidad] | 97.52h | 58.51h | 1,064,486.25 | 1,064,486.25 | 644,684.58 |
| 34 | 1.5.2.2 | PRUEBAS |  | 5.5d | 2022-02-21 | 2022-03-01 | 33 |  |  | 2022-02-21 | 2022-03-01 | 5.5d | 0d | Ingeniero de sistemas [50%]; Celular [1 x mensualidad]; Computador [1 x mensualidad]; Plan de minutos /Datos [1 x mensualidad] | 24.75h |  | 367,179.25 | 367,179.25 |  |
| 35 | 1.6 | **GERENCIA** |  | 37.66d | 2022-03-01 | 2022-04-26 |  |  |  | 2022-03-01 | 2022-04-26 | 37.66d | 0d |  | 335.48h |  | 7,580,556.81 | 7,580,556.81 |  |
| 36 | 1.6.1 | **WORK SHOP** |  | 16.33d | 2022-03-01 | 2022-03-24 |  |  |  | 2022-03-01 | 2022-03-24 | 16.33d | 0d |  | 73.48h |  | 1,134,851.75 | 1,134,851.75 |  |
| 37 | 1.6.1.1 | NIVEL ADMINISTRATIVO |  | 11d | 2022-03-01 | 2022-03-16 | 27, 34 |  |  | 2022-03-01 | 2022-03-16 | 11d | 0d | Ingenieros de proyectos [50%]; Ingeniero de sistemas [50%]; Celular [2 x mensualidad]; Computador [2 x mensualidad]; Plan de minutos /Datos [2 x mensualidad] | 49.5h |  | 755,000 | 755,000 |  |
| 38 | 1.6.1.2 | NIVEL OPERATIVO |  | 5.33d | 2022-03-16 | 2022-03-24 | 37 |  |  | 2022-03-16 | 2022-03-24 | 5.33d | 0d | Ingenieros de proyectos [50%]; Celular [1 x mensualidad]; Computador [1 x mensualidad]; Plan de minutos /Datos [1 x mensualidad] | 23.98h |  | 379,851.75 | 379,851.75 |  |
| 39 | 1.6.2 | **ACTA DE FINALIZACION** |  | 21.33d | 2022-03-24 | 2022-04-26 |  |  |  | 2022-03-24 | 2022-04-26 | 21.33d | 0d |  | 262h |  | 6,445,705.06 | 6,445,705.06 |  |
| 40 | 1.6.2.1 | ENTREGA DE DOCUMENTACION |  | 15.83d | 2022-03-24 | 2022-04-19 | 38 |  |  | 2022-03-24 | 2022-04-19 | 15.83d | 0d | Gerente de Proyectos [40%]; Ingeniero ambiental [10%]; Ingeniero de sistemas [40%]; Ingenieros de proyectos [40%]; Tecnico de proyectos [40%]; Impresora [1 x mensualidad]; Papel [1 x resma]; Celular [5 x mensualidad]; Computador [5 x mensualidad]; Plan de minutos /Datos [1 x mensualidad] | 242.2h |  | 3,522,016.5 | 3,522,016.5 |  |
| 41 | 1.6.2.2 | ACTA DE CIERRE DEL PROYECTO |  | 5.5d | 2022-04-19 | 2022-04-26 | 38, 40 |  |  | 2022-04-19 | 2022-04-26 | 5.5d | 0d | Gerente de Proyectos [40%]; Celular [1 x mensualidad]; Computador [1 x mensualidad]; Impresora [1 x mensualidad]; Plan de minutos /Datos [1 x mensualidad]; Papel [1 x resma] | 19.8h |  | 533,250 | 533,250 |  |
| 42 | 1.6.2.3 | Fin de proyecto | milestone, manual | 0d | 2022-04-26 | 2022-04-26 | 41 |  |  | 2022-04-26 | 2022-04-26 | 0d |  | Gerente de Proyectos [40%] |  |  |  |  |  |
| 43 | 1.6.2.4 | RESERVA DE CONTINGENCIA | manual | 1d? | 2022-03-24 | 2022-03-25 |  |  |  | 2022-03-24 | 2022-03-25 | 1d? |  |  |  |  | 2,390,438.56 | 2,390,438.56 |  |
